# Opletalova 47,49

Schedule from MS Project, 2021-11-30 to 2024-11-30, 24 hours a day.

## Calendars

- 24 hodin: Mon-Sun 00:00-24:00.

## Resources

| Resource |
| --- |
| 21dní podlaží |
| 1pp ,1np,2np… |

## Schedule

| ID | WBS | Task | Duration | Start | Finish | Predecessors | Total slack | Free slack | Constraint |
| --- | --- | --- | --- | --- | --- | --- | --- | --- | --- |
| 1 | 1 | **Opletalova 47,49** | 1096d | 2021-11-30 | 2024-11-30 |  | 0d |  |  |
| 2 | 1.1 | zařízení staveniště | 1090d | 2021-11-30 | 2024-11-24 |  | 6d |  | start no earlier than 2021-11-30 |
| 3 | 1.2 | příprava stavenište, vč.pasportizace, odvezení prvků k restaurování | 21d | 2021-11-30 | 2021-12-21 |  | 75d | 0d | start no earlier than 2021-11-30 |
| 4 | 1.3 | uskladnění prvků k restaurování v dílně | 1000d | 2021-12-21 | 2024-09-16 | 3 | 75d |  |  |
| 5 | 1.4 | **bourací práce** | 127d | 2021-12-21 | 2022-04-27 | 3 | 611d |  |  |
| 6 | 1.4.1 | knihovna | 30d | 2021-12-21 | 2022-01-20 |  | 611d | 0d |  |
| 7 | 1.4.2 | dvůr objektu 47 | 14d | 2022-01-13 | 2022-01-27 | 6FS-7d | 473d | 0d |  |
| 8 | 1.4.3 | objekt 47 a 49 | 90d | 2022-01-27 | 2022-04-27 | 7 | 473d | 0d |  |
| 9 | 1.5 | **výkopové práce** | 76d | 2022-01-13 | 2022-03-30 |  | 611d |  |  |
| 10 | 1.5.1 | dvůr objektu 47/ knihovna + kotvení | 42d | 2022-01-13 | 2022-02-24 | 7SS | 577d | 0d |  |
| 11 | 1.5.2 | objekt 47 | 20d | 2022-02-24 | 2022-03-16 | 10 | 969d | 0d |  |
| 12 | 1.5.3 | objekt 49 | 14d | 2022-03-16 | 2022-03-30 | 11 | 976d |  |  |
| 13 | 1.6 | **zakládání** | 110d | 2022-02-03 | 2022-05-24 |  | 632d |  |  |
| 14 | 1.6.1 | bárky knihovna - zřízení i odstranění | 110d | 2022-02-03 | 2022-05-24 | 10FS-21d | 921d |  |  |
| 15 | 1.6.2 | injektáž dvůr 47 | 21d | 2022-02-24 | 2022-03-17 | 10 | 577d | 0d |  |
| 16 | 1.6.3 | injektáž objekt 47 | 21d | 2022-03-16 | 2022-04-06 | 11 | 969d |  |  |
| 17 | 1.7 | **monolit dvůr 47** | 62d | 2022-03-20 | 2022-05-21 |  | 611d |  |  |
| 18 | 1.7.1 | základová deska | 14d | 2022-03-20 | 2022-04-03 | 15FS+3d | 577d | 0d |  |
| 19 | 1.7.2 | monolit 2PP | 21d | 2022-04-06 | 2022-04-27 | 18FS+3d | 577d | 0d |  |
| 20 | 1.7.3 | monolit 1PP | 21d | 2022-04-30 | 2022-05-21 | 19FS+3d | 577d | 0d |  |
| 21 | 1.8 | věžový jeřáb | 358d | 2022-04-06 | 2023-03-30 | 18FS+3d | 611d |  |  |
| 22 | 1.9 | přípojky (ZTI a ele - přeložky) a retenční nádrže | 60d | 2022-05-21 | 2022-07-20 | 20 | 864d |  |  |
| 23 | 1.10 | **nosná konstrukce** | 337d | 2022-04-27 | 2023-03-30 |  | 611d |  |  |
| 24 | 1.10.1 | knihovna - nový strop 4NP | 28d | 2022-06-11 | 2022-07-09 | 20FS+21d | 577d | 0d | start no earlier than 2022-05-09 |
| 25 | 1.10.2 | knihovna - nástavba 5NP | 28d | 2022-07-09 | 2022-08-06 | 24 | 577d | 0d | start no earlier than 2022-05-09 |
| 26 | 1.10.3 | objekt 47 - nový strop 4NP a střecha 5NP | 45d | 2022-08-06 | 2022-09-20 | 25 | 802d |  |  |
| 27 | 1.10.4 | objekt 49 - nová střecha | 50d | 2022-04-27 | 2022-06-16 | 8 | 473d | 0d |  |
| 28 | 1.10.5 | přesun arkýře mezi 47 a 49 - konstrukce | 14d | 2022-06-16 | 2022-06-30 | 27 | 698d | 0d |  |
| 29 | 1.10.6 | objekt 49 - nový strop 3NP | 40d | 2022-06-16 | 2022-07-26 | 27 | 633d |  |  |
| 30 | 1.10.7 | objekt 47 a 49 - stropy, záklop | 70d | 2022-06-30 | 2022-09-08 | 28 | 473d | 0d |  |
| 31 | 1.10.8 | objekt 47 - nové výtahové šachty a schodiště | 60d | 2022-09-08 | 2022-11-07 | 30 | 473d | 0d |  |
| 32 | 1.10.9 | objekt 47 - nový výtah na dvoře - konstrukce | 21d | 2022-11-07 | 2022-11-28 | 31 | 473d | 0d |  |
| 33 | 1.10.10 | objekt 47 - přístavba na dvoře 1NP | 14d | 2022-11-28 | 2022-12-12 | 32 | 473d | 0d |  |
| 34 | 1.10.11 | objekt 47 - vložený strop knihovny 1NP | 21d | 2022-12-12 | 2023-01-02 | 33 | 473d |  | start no earlier than 2022-09-15 |
| 35 | 1.10.12 | objekt 47 - nové pavlače a prosklená kce dvora | 60d | 2023-01-29 | 2023-03-30 | 36 | 372d | 0d |  |
| 36 | 1.11 | výplně stavebních otvorů | 60d | 2022-11-30 | 2023-01-29 |  | 372d | 0d | start no earlier than 2022-11-30 |
| 37 | 1.12 | přesun trafostanice | 35d | 2023-01-29 | 2023-03-05 | 36 | 563d | 0d |  |
| 38 | 1.13 | hrubé rozvody elektro | 21d | 2023-03-12 | 2023-04-02 | 37FS+7d | 563d | 0d |  |
| 39 | 1.14 | hrubé rozvody TZB | 45d | 2023-04-02 | 2023-05-17 | 38 | 103d | 0d |  |
| 40 | 1.15 | podkladní vrstvy podlah | 60d | 2023-01-29 | 2023-03-30 | 36 | 611d |  |  |
| 41 | 1.16 | sanace | 65d | 2022-09-08 | 2022-11-12 | 30 | 749d |  |  |
| 42 | 1.17 | fasáda | 90d | 2023-04-15 | 2023-07-14 |  | 399d | 0d | start no earlier than 2023-04-15 |
| 43 | 1.18 | klempířske konstrukce | 80d | 2023-07-19 | 2023-10-07 | 42FS+5d | 399d | 0d | start no earlier than 2020-07-01 |
| 44 | 1.19 | zámečnické konstrukce | 80d | 2023-08-09 | 2023-10-28 | 43SS+21d | 399d |  |  |
| 45 | 1.20 | truhlářské konstrukce | 60d | 2023-09-30 | 2023-11-29 |  | 366.62d |  | finish no earlier than 2023-11-29 |
| 46 | 1.21 | objekt 47 - úprava jednoho patra k využití pro kanceláře stavby, vč.omítek, maleb a podlah | 40d | 2023-05-17 | 2023-06-26 | 39 | 523d |  |  |
| 47 | 1.22 | příčkové a dělící kce | 60d | 2023-01-11 | 2023-03-12 | 38SF | 629d |  |  |
| 48 | 1.23 | rozvody čisté TZB a elektro | 60d | 2023-08-01 | 2023-09-30 | 39FS+45d | 72d | 0d | start no earlier than 2023-08-01 |
| 49 | 1.24 | omítky a podhledy | 60d | 2023-09-30 | 2023-11-29 | 48 | 72d | 0d |  |
| 50 | 1.25 | výtahy - montáž | 21d | 2023-11-29 | 2023-12-20 | 49 | 346d |  |  |
| 51 | 1.26 | obklady hygienických zázemí | 60d | 2023-11-29 | 2024-01-28 | 49 | 307d |  |  |
| 52 | 1.27 | malby | 60d | 2023-12-04 | 2024-02-02 | 49FS+5d | 72d | 0d |  |
| 53 | 1.28 | kompletace vzt ,ele,zti | 60d | 2023-12-04 | 2024-02-02 | 52SS | 302d |  | start no earlier than 2020-08-03 |
| 54 | 1.29 | restaurátorské práce | 110d | 2024-02-02 | 2024-05-22 | 52 | 192d |  |  |
| 55 | 1.30 | podlahové krytiny | 120d | 2024-01-23 | 2024-05-22 | 52FS-10d | 72d | 0d |  |
| 56 | 1.31 | inter.dveře | 60d | 2024-05-22 | 2024-07-21 | 55 | 132d |  | start no earlier than 2020-12-01 |
| 57 | 1.32 | interiérové vybavení | 120d | 2024-05-22 | 2024-09-19 | 55 | 72d |  |  |
| 58 | 1.33 | sadové úpravy/ zelené střechy | 60d | 2024-07-26 | 2024-09-24 |  | 66.62d |  | finish no earlier than 2024-09-24 |
| 59 | 1.34 | ostatní kompletační práce | 30d | 2024-08-25 | 2024-09-24 |  | 66.62d |  | finish no earlier than 2024-09-24 |
| 60 | 1.35 | finální úklidy | 60d | 2024-09-24 | 2024-11-23 | 62FF-7d | 7d |  |  |
| 61 | 1.36 | mobilní nábytek | 30d | 2024-10-24 | 2024-11-23 | 62FF-7d | 7d |  |  |
| 62 | 1.37 | příprava ke kolaudaci | 30d | 2024-10-31 | 2024-11-30 |  | 0d |  | start no earlier than 2024-10-31 |
